# SAMPLE_PROJECT

Schedule from MS Project, 2013-03-15 to 2013-06-20, costs in $, A marks actual dates.
Toshiba

## Calendars

- Standard: Mon-Fri 08:00-12:00, 13:00-17:00; Sat-Sun off.
- SAMPLE: Mon-Sat 08:00-12:00, 13:00-17:00; Sun off.

## Resources

| Resource | Unit | Rate |
| --- | --- | --- |
| ENGINEER |  | 25 |
| SUPERVISOR |  | 6.25 |
| LABOR |  | 2.5 |
| MASON |  | 3.75 |
| EXCAVATOR |  | 125 |
| TRACTOR |  | 62.5 |
| CEMENT | BAG | 15 |
| CONCRETE | CUM | 85 |
| SAND | CUM | 12 |
| BRICK | CUM | 500 |
| FOREMAN |  | 9.38 |
| AGGREGATE | CUM | 20 |
| PVC PIPES | LENGTH | 1.6 |
| CONDUITES | LENGTH | 1.5 |
| STEEL | TONN | 3000 |
| PLY BOARDS | NUMBER | 29 |
| GLASS |  | 30 |
| DOORS |  | 260 |
| ELECTRICIAN |  | 3.75 |
| PLUMBER |  | 3.75 |
| CARPENTER |  | 5 |
| BAR BINDERS |  | 5 |

## Schedule

| ID | WBS | Task | Type | Duration | Start | Finish | Predecessors | Complete | Actual start | Actual finish | Calendar | Resources | Work | Actual work | Cost | Actual cost |
| --- | --- | --- | --- | --- | --- | --- | --- | --- | --- | --- | --- | --- | --- | --- | --- | --- |
| 1 | 1 | **START OF A PROJECT** |  | 73d | 2013-03-15 A | 2013-06-07 A |  | 100% |  |  | SAMPLE |  | 10968h | 10968h | 156,111.5 | 156,111.5 |
| 2 | 1.1 | **PREPARING GROUND** |  | 11d | 2013-03-15 A | 2013-03-27 A |  | 100% |  |  | SAMPLE |  | 888h | 888h | 15,151.6 | 15,151.6 |
| 3 | 1.1.1 | EXCAVATION | manual | 1d | 2013-03-15 A | 2013-03-15 A |  | 100% |  |  | SAMPLE | EXCAVATOR; LABOR [200%]; TRACTOR | 32h | 32h | 1,540 | 1,540 |
| 4 | 1.1.2 | FOUNDATION | manual | 4d | 2013-03-16 A | 2013-03-20 A |  | 100% |  |  | SAMPLE | CONCRETE [32 CUM]; LABOR [600%]; MASON [400%]; ENGINEER; FOREMAN; STEEL [0.6 TONN] | 384h | 384h | 6,580 | 6,580 |
| 5 | 1.1.3 | DPC | manual | 2d | 2013-03-21 A | 2013-03-22 A |  | 100% |  |  | SAMPLE | BRICK [6 CUM]; CEMENT [10 BAG]; FOREMAN; LABOR; MASON [400%]; SAND [1.8 CUM]; SUPERVISOR | 112h | 112h | 3,701.6 | 3,701.6 |
| 6 | 1.1.4 | LAYING OF PCC | manual | 3d | 2013-03-25 A | 2013-03-27 A |  | 100% |  |  | SAMPLE | BRICK [1.5 CUM]; CONCRETE [15 CUM]; FOREMAN; LABOR [800%]; MASON [500%]; SUPERVISOR | 360h | 360h | 3,330 | 3,330 |
| 7 | 1.2 | **GROUND FLOOR** |  | 20d | 2013-03-28 A | 2013-04-19 A |  | 100% |  |  | SAMPLE |  | 2160h | 2160h | 69,453.5 | 69,453.5 |
| 8 | 1.2.1 | COLUMNS | manual | 7d | 2013-03-28 A | 2013-04-04 A |  | 100% |  |  | SAMPLE | STEEL [2.5 TONN]; CONCRETE [122.5 CUM]; ENGINEER; LABOR [300%]; MASON [200%]; PLY BOARDS [200 NUMBER]; BAR BINDERS [500%] | 576h | 576h | 27,152.5 | 27,152.5 |
| 9 | 1.2.2 | WALLS | manual | 13d | 2013-04-05 A | 2013-04-19 A | 8SS | 100% |  |  | SAMPLE | BRICK [50 CUM]; CEMENT [400 BAG]; ENGINEER; FOREMAN; LABOR [600%]; MASON [400%]; SAND [70 CUM] | 1248h | 1248h | 38,535 | 38,535 |
| 10 | 1.2.3 | ELECT & PLUMBING | manual | 7d | 2013-04-08 A | 2013-04-15 A | 9SS | 100% |  |  | SAMPLE | CONDUITES [60 LENGTH]; PVC PIPES [60 LENGTH]; ELECTRICIAN [300%]; PLUMBER [200%] | 240h | 240h | 1,086 | 1,086 |
| 11 | 1.2.4 | DOORS & WINDOW FRAME | manual | 7d | 2013-04-08 A | 2013-04-15 A | 8SS | 100% |  |  | SAMPLE | DOORS [800%]; GLASS [400%]; CARPENTER [200%] | 96h | 96h | 2,680 | 2,680 |
| 12 | 1.3 | **STAIR CASE** |  | 20d | 2013-04-01 A | 2013-04-23 A |  | 100% |  |  | SAMPLE |  | 984h | 984h | 6,671.4 | 6,671.4 |
| 13 | 1.3.1 | SHUTTERING | manual | 5d | 2013-04-01 A | 2013-04-05 A |  | 100% |  |  | SAMPLE | CARPENTER [700%]; PLY BOARDS [4 NUMBER] | 280h | 280h | 1,516 | 1,516 |
| 14 | 1.3.2 | STEEL BINDING | manual | 6d | 2013-04-02 A | 2013-04-08 A |  | 100% |  |  | SAMPLE | BAR BINDERS [500%]; STEEL [0.2 TONN] | 200h | 200h | 1,600 | 1,600 |
| 15 | 1.3.3 | LAYING OF CONCRETE | manual | 4d | 2013-04-09 A | 2013-04-12 A |  | 100% |  |  | SAMPLE | CONCRETE [0.6 CUM]; ENGINEER; LABOR [400%]; MASON [200%] | 224h | 224h | 1,411 | 1,411 |
| 16 | 1.3.4 | BRICK WORK FOR STEPS | manual | 7d | 2013-04-16 A | 2013-04-23 A |  | 100% |  |  | SAMPLE | BRICK [1.5 CUM]; CEMENT [20 BAG]; LABOR [200%]; MASON [200%]; SAND [3.7 CUM]; SUPERVISOR | 280h | 280h | 2,144.4 | 2,144.4 |
| 17 | 1.4 | **ROOF** |  | 15d | 2013-04-16 A | 2013-05-02 A |  | 100% |  |  | SAMPLE |  | 2552h | 2552h | 22,634.5 | 22,634.5 |
| 18 | 1.4.1 | **BEAM** |  | 6d | 2013-04-26 | 2013-05-02 |  | 100% | 2013-04-16 | 2013-04-30 | SAMPLE |  | 1400h | 1400h | 8,852.5 | 8,852.5 |
| 19 | 1.4.1.1 | SHUTTERING | manual | 7d | 2013-04-16 A | 2013-04-23 A |  | 100% |  |  | SAMPLE | CARPENTER [700%]; LABOR [700%]; PLY BOARDS [45 NUMBER] | 392h | 392h | 2,285 | 2,285 |
| 20 | 1.4.1.2 | STEEL BINDING | manual | 7d | 2013-04-16 A | 2013-04-23 A | 19SS | 100% |  |  | SAMPLE | STEEL [0.3 TONN]; BAR BINDERS [1000%] | 480h | 480h | 3,300 | 3,300 |
| 21 | 1.4.1.3 | LAYING CONCRETE | manual | 6d | 2013-04-24 A | 2013-04-30 A | 20 | 100% |  |  | SAMPLE | CONCRETE [3.5 CUM]; ENGINEER; FOREMAN; LABOR [500%]; MASON [400%] | 528h | 528h | 3,267.5 | 3,267.5 |
| 22 | 1.4.2 | **SLAB** |  | 7d | 2013-04-24 A | 2013-05-02 A |  | 100% |  |  |  |  | 1152h | 1152h | 13,782 | 13,782 |
| 23 | 1.4.2.1 | SHUTTERING | manual | 7d | 2013-04-24 A | 2013-05-01 A |  | 100% |  |  | SAMPLE | CARPENTER [700%]; LABOR [400%]; PLY BOARDS [73 NUMBER] | 560h | 560h | 4,357 | 4,357 |
| 24 | 1.4.2.2 | STEEL BINDING | manual | 7d | 2013-04-24 A | 2013-05-01 A | 23SS | 100% |  |  | SAMPLE | BAR BINDERS [1000%]; STEEL [1.7 TONN] | 480h | 480h | 7,500 | 7,500 |
| 25 | 1.4.2.3 | LAYING CONCRETE | manual | 1d | 2013-05-02 A | 2013-05-02 A |  | 100% |  |  | SAMPLE | CONCRETE [16 CUM]; ENGINEER; FOREMAN; LABOR [700%]; MASON [500%] | 112h | 112h | 1,925 | 1,925 |

| ID | WBS | Task | Type | Duration | Start | Finish | Complete | Calendar | Resources | Work | Actual work | Cost | Actual cost |
| --- | --- | --- | --- | --- | --- | --- | --- | --- | --- | --- | --- | --- | --- |
| 26 | 1.5 | **TOP ROOF** |  | 11d | 2013-05-09 A | 2013-05-21 A | 100% | SAMPLE |  | 2352h | 2352h | 12,600.5 | 12,600.5 |
| 27 | 1.5.1 | BEAM | manual | 10d | 2013-05-09 A | 2013-05-20 A | 100% | SAMPLE | BAR BINDERS [700%]; CARPENTER [700%]; CONCRETE [0.5 CUM]; LABOR [500%]; MASON [300%]; PLY BOARDS [6 NUMBER]; STEEL [0.05 TONN] | 1088h | 1088h | 4,506.5 | 4,506.5 |
| 28 | 1.5.2 | SLAB | manual | 11d | 2013-05-09 A | 2013-05-21 A | 100% | SAMPLE | BAR BINDERS [500%]; CARPENTER [400%]; CONCRETE [1 CUM]; ENGINEER; LABOR [300%]; MASON [300%]; PLY BOARDS [11 NUMBER]; STEEL [0.2 TONN] | 1264h | 1264h | 8,094 | 8,094 |
| 29 | 1.6 | RAILING | manual | 4d | 2013-05-23 A | 2013-05-27 A | 100% | SAMPLE |  |  |  |  |  |
| 30 | 1.7 | BOUNDARY WALL | manual | 10d | 2013-05-28 A | 2013-06-07 A | 100% | SAMPLE | BAR BINDERS [1000%]; CARPENTER [400%]; CONCRETE [60 CUM]; ENGINEER; EXCAVATOR; LABOR [600%]; MASON [400%]; PLY BOARDS [50 NUMBER]; STEEL [1 TONN] | 1968h | 1968h | 28,990 | 28,990 |
| 31 | 1.8 | **FINISHING** |  | 5d | 2013-05-23 A | 2013-05-28 A | 100% | SAMPLE |  | 64h | 64h | 610 | 610 |
| 32 | 1.8.1 | DOORS | manual | 5d | 2013-05-23 A | 2013-05-28 A | 100% | SAMPLE | CARPENTER; DOORS | 32h | 32h | 420 | 420 |
| 33 | 1.8.2 | WINDOW GLASS | manual | 5d | 2013-05-23 A | 2013-05-28 A | 100% | SAMPLE | CARPENTER; GLASS | 32h | 32h | 190 | 190 |
| 34 | 2 | END OF PROJECT | manual | 1d | 2013-06-20 A | 2013-06-20 A | 100% | SAMPLE |  |  |  |  |  |
